# HIE Technology and Workflow Project Plan (MeHI)

Schedule from MS Project, 2018-02-05 to 2018-07-23.

## Calendars

- Standard: Mon-Fri 08:00-12:00, 13:00-17:00; Sat-Sun off.

## Resources

| Resource |
| --- |
| project sponsor |
| Project Manager |
| Sponsor |
| Partner IT |
| IT |
| Care Staff Rep |
| Legal |
| Partner Care rep |
| Vendor A |
| Vendor B |
| Team |
| Training Resource |

## Schedule

| ID | WBS | Task | Duration | Start | Finish | Predecessors | Total slack | Free slack | Resources | Work |
| --- | --- | --- | --- | --- | --- | --- | --- | --- | --- | --- |
| 1 | 1 | **HIE Integration** | 121d | 2018-02-05 | 2018-07-23 |  |  |  |  | 7368h |
| 2 | 1.1 | **Project Set up** | 10d | 2018-02-05 | 2018-02-16 |  | 0d |  |  | 352h |
| 3 | 1.1.1 | Identify project manager | 1d | 2018-02-05 | 2018-02-05 |  | 0d |  | Sponsor | 8h |
| 4 | 1.1.2 | Document Project Description | 4d | 2018-02-06 | 2018-02-09 | 3 | 116d |  | Project Manager | 32h |
| 5 | 1.1.3 | Document Proposed project timeline estimate | 4d | 2018-02-06 | 2018-02-09 | 3 | 0d |  | Project Manager | 32h |
| 6 | 1.1.4 | **Document Project Value** | 5d | 2018-02-12 | 2018-02-16 |  | 111d |  | Project Manager | 280h |
| 7 | 1.1.4.1 | **Project goals** | 5d | 2018-02-12 | 2018-02-16 |  | 111d |  |  | 80h |
| 8 | 1.1.4.1.1 | Patient care improvements | 5d | 2018-02-12 | 2018-02-16 | 5 | 111d |  | Project Manager | 40h |
| 9 | 1.1.4.1.2 | operational improvements | 5d | 2018-02-12 | 2018-02-16 | 5 | 111d |  | Project Manager | 40h |
| 10 | 1.1.4.2 | Quantify project objectives | 5d | 2018-02-12 | 2018-02-16 | 5 | 111d |  | Project Manager | 40h |
| 11 | 1.1.4.3 | **Financial benefits** | 5d | 2018-02-12 | 2018-02-16 |  | 111d |  |  | 120h |
| 12 | 1.1.4.3.1 | regulatory mandates | 5d | 2018-02-12 | 2018-02-16 | 5 | 111d |  | Project Manager | 40h |
| 13 | 1.1.4.3.2 | ACO participation requirement | 5d | 2018-02-12 | 2018-02-16 | 5 | 111d |  | Project Manager | 40h |
| 14 | 1.1.4.3.3 | Operational improvements | 5d | 2018-02-12 | 2018-02-16 | 5 | 111d |  | Project Manager | 40h |
| 15 | 1.2 | **Confirm Internal Organization support** | 15d | 2018-02-12 | 2018-03-02 |  | 0d |  |  | 440h |
| 16 | 1.2.1 | Leadership | 5d | 2018-02-12 | 2018-02-16 | 5 | 0d |  | Sponsor | 40h |
| 17 | 1.2.2 | Direct care staff | 10d | 2018-02-19 | 2018-03-02 | 16 | 1d | 0d | Sponsor | 80h |
| 18 | 1.2.3 | IT | 10d | 2018-02-19 | 2018-03-02 | 16 | 81d | 0d | Sponsor | 80h |
| 19 | 1.2.4 | Other departments | 10d | 2018-02-19 | 2018-03-02 | 16 | 81d |  | Sponsor | 80h |
| 20 | 1.2.5 | **Confirm Project Budget** | 10d | 2018-02-19 | 2018-03-02 | 16 | 81d |  |  | 160h |
| 21 | 1.2.5.1 | IT systems changes or upgrades | 10d | 2018-02-19 | 2018-03-02 | 16 | 81d |  | Project Manager | 80h |
| 22 | 1.2.5.2 | Staff and other resources | 10d | 2018-02-19 | 2018-03-02 | 16 | 81d |  | Project Manager | 80h |
| 23 | 1.3 | **Organize Staffing** | 20d | 2018-03-05 | 2018-03-30 |  | 1d |  |  | 280h |
| 24 | 1.3.1 | **Internal** | 5d | 2018-03-05 | 2018-03-09 |  | 1d |  |  | 120h |
| 25 | 1.3.1.1 | Identify Direct care staff representative | 5d | 2018-03-05 | 2018-03-09 | 17 | 1d | 0d | Project Manager | 40h |
| 26 | 1.3.1.2 | IT resource | 5d | 2018-03-05 | 2018-03-09 | 18 | 91d | 0d | Project Manager | 40h |
| 27 | 1.3.1.3 | Other | 5d | 2018-03-05 | 2018-03-09 | 18 | 96d |  | Project Manager | 40h |

Notes:
- 4: Include the problem that this project addresses
- 5: Include key dates and milestones
- 7: Goals are the expected positive outcomes of completing this project
- 10: Measurable items. # of transactions /month
- 16: Confirm this project fits with the organizaton's strategic goals and will be supported throughout
- 17: Ensure staff buy in. reduce negativity and apathy
- 18: Must be priority
- 19: Training, HR, Finance
- 27: Training, HR, Finance

| ID | WBS | Task | Duration | Start | Finish | Predecessors | Total slack | Free slack | Resources | Work |
| --- | --- | --- | --- | --- | --- | --- | --- | --- | --- | --- |
| 28 | 1.3.2 | **External additional resources** | 20d | 2018-03-05 | 2018-03-30 |  | 81d |  |  | 160h |
| 29 | 1.3.2.1 | Work estimates and tasks | 10d | 2018-03-05 | 2018-03-16 | 15 | 81d | 0d | Project Manager | 80h |
| 30 | 1.3.2.2 | contract resources | 10d | 2018-03-19 | 2018-03-30 | 29 | 81d |  | Project Manager | 80h |
| 31 | 1.4 | **Confim Trading Partner cooperation** | 15d | 2018-02-19 | 2018-03-09 |  | 0d |  |  | 160h |
| 32 | 1.4.1 | Leadership support | 5d | 2018-02-19 | 2018-02-23 | 16 | 0d |  |  |  |
| 33 | 1.4.2 | Identify Project manager/key contacat | 5d | 2018-02-26 | 2018-03-02 | 32 | 0d |  | Project Manager | 40h |
| 34 | 1.4.3 | Direct care Staff | 5d | 2018-03-05 | 2018-03-09 | 33 | 71d |  | Project Manager | 40h |
| 35 | 1.4.4 | IT | 5d | 2018-03-05 | 2018-03-09 | 33 | 0d |  | Project Manager | 40h |
| 36 | 1.4.5 | Other | 5d | 2018-03-05 | 2018-03-09 | 33 | 71d |  | Project Manager | 40h |
| 37 | 1.5 | Identify sending and receiving vendor contacts | 5d | 2018-03-12 | 2018-03-16 | 31 | 86d | 0d | Project Manager | 40h |
| 38 | 1.6 | Hold Kick-off meeting | 5d | 2018-03-19 | 2018-03-23 | 37 | 86d |  | Project Manager | 40h |
| 39 | 1.7 | **Confirm feasiblity of transaction with vendors** | 25d | 2018-03-12 | 2018-04-13 |  | 0d |  |  | 1440h |
| 40 | 1.7.1 | Confirm internal system capability | 5d | 2018-03-12 | 2018-03-16 | 26 | 91d |  | IT; Vendor A | 80h |
| 41 | 1.7.2 | Confirm trading partner system capability | 5d | 2018-03-12 | 2018-03-16 | 35 | 0d |  | Partner IT; Vendor A | 80h |
| 42 | 1.7.3 | Transaction data agreed | 10d | 2018-03-19 | 2018-03-30 | 41 | 81d |  | IT; Partner IT; Care Staff Rep; Vendor B | 320h |
| 43 | 1.7.4 | Transport method agreed | 10d | 2018-03-19 | 2018-03-30 | 41 | 81d |  | IT; Partner IT | 160h |
| 44 | 1.7.5 | Ttransaction timing/frequency agreed | 10d | 2018-03-19 | 2018-03-30 | 41 | 81d |  | Care Staff Rep; IT; Partner IT | 240h |
| 45 | 1.7.6 | Document Business and Clinical rules | 10d | 2018-03-19 | 2018-03-30 | 41 | 76d | 5d | Project Manager; IT; Partner IT; Vendor A; Vendor B | 400h |
| 46 | 1.7.7 | Document system changes required | 10d | 2018-03-19 | 2018-03-30 | 41 | 0d |  | Project Manager | 80h |
| 47 | 1.7.8 | contract for any required changes | 10d | 2018-04-02 | 2018-04-13 | 46 | 0d |  | Project Manager | 80h |
| 48 | 1.8 | **IT systems** | 10d | 2018-03-05 | 2018-03-16 |  | 91d |  |  | 80h |
| 49 | 1.8.1 | Ensure proper modules purchased, implemented and accessible | 5d | 2018-03-05 | 2018-03-09 | 18 | 91d | 0d | IT | 40h |
| 50 | 1.8.2 | Ensure User authentication, authorizations and other admin are complete | 5d | 2018-03-12 | 2018-03-16 | 49 | 91d |  | IT | 40h |
| 51 | 1.9 | **Legal Considerations** | 30d | 2018-02-12 | 2018-03-23 |  | 86d |  |  | 720h |
| 52 | 1.9.1 | Consent | 30d | 2018-02-12 | 2018-03-23 | 5 | 86d |  | Legal | 240h |
| 53 | 1.9.2 | BAA | 30d | 2018-02-12 | 2018-03-23 | 5 | 86d |  | Legal | 240h |
| 54 | 1.9.3 | 42 CFR part 2 | 30d | 2018-02-12 | 2018-03-23 | 5 | 86d |  | Legal | 240h |

Notes:
- 28: Back fill or support for key staff, IT resources
- 40: EHR system, HISP HIway Connection
- 41: EHR system, HISP HIway Connection
- 42: Assuming structured data,
- 43: Direct, VPN, SFTP other
- 44: How is the transaction triggered an how/when will it be sent? Batch, real-time
- 47: With vendor or contractor developing the interface
- 49: Each system must be able to send and receive
- 50: All appropriate users must be able to access information

| ID | WBS | Task | Type | Duration | Start | Finish | Predecessors | Total slack | Free slack | Resources | Work |
| --- | --- | --- | --- | --- | --- | --- | --- | --- | --- | --- | --- |
| 55 | 1.10 | **Develop Implementation project plan** |  | 5d | 2018-04-02 | 2018-04-06 |  | 76d |  |  | 120h |
| 56 | 1.10.1 | Document project requirements |  | 5d | 2018-04-02 | 2018-04-06 | 46 | 76d |  | Project Manager | 40h |
| 57 | 1.10.2 | Revise time estimate |  | 5d | 2018-04-02 | 2018-04-06 | 46 | 76d |  | Project Manager | 40h |
| 58 | 1.10.3 | Develop Contingency/Bail-out Plan |  | 5d | 2018-04-02 | 2018-04-06 | 46 | 76d |  | Project Manager | 40h |
| 59 | 1.11 | **Revise Operational workflow** |  | 30d | 2018-03-12 | 2018-04-20 |  | 1d |  |  | 1120h |
| 60 | 1.11.1 | **evaluate current operational workflow** |  | 10d | 2018-03-12 | 2018-03-23 |  | 1d |  |  | 320h |
| 61 | 1.11.1.1 | Sending organization workflow flowchart |  | 10d | 2018-03-12 | 2018-03-23 | 25 | 1d | 0d | Project Manager; Care Staff Rep | 160h |
| 62 | 1.11.1.2 | Receiving organization workflow flowchart |  | 10d | 2018-03-12 | 2018-03-23 | 31 | 71d | 0d | Project Manager; Partner Care rep | 160h |
| 63 | 1.11.2 | **Document Future workflow** |  | 10d | 2018-03-26 | 2018-04-06 |  | 1d | 0d |  | 640h |
| 64 | 1.11.2.1 | Document Sending organization Procedures |  | 10d | 2018-03-26 | 2018-04-06 | 61 | 1d | 0d | Project Manager; Care Staff Rep | 160h |
| 65 | 1.11.2.2 | **Document downtime/ Emergency workflow** |  | 10d | 2018-03-26 | 2018-04-06 |  | 71d |  | Project Manager; Care Staff Rep | 160h |
| 66 | 1.11.2.2.1 | Hard copy documents and forms |  | 10d | 2018-03-26 | 2018-04-06 | 61 | 71d |  |  |  |
| 67 | 1.11.2.2.2 | Fax Numbers and Contact Numbers |  | 10d | 2018-03-26 | 2018-04-06 | 61 | 71d |  |  |  |
| 68 | 1.11.2.3 | Document Receiving organization Procedures |  | 10d | 2018-03-26 | 2018-04-06 | 62 | 71d |  | Partner Care rep | 80h |
| 69 | 1.11.2.4 | **Document downtime/ Emergency workflow** |  | 10d | 2018-03-26 | 2018-04-06 |  | 71d |  | Care Staff Rep; IT; Project Manager | 240h |
| 70 | 1.11.2.4.1 | Hard copy documents and forms |  | 10d | 2018-03-26 | 2018-04-06 | 61 | 71d |  |  |  |
| 71 | 1.11.2.4.2 | Fax Numbers and Contact Numbers |  | 10d | 2018-03-26 | 2018-04-06 | 61 | 71d |  |  |  |
| 72 | 1.11.3 | **Develop Work flow training plan** |  | 10d | 2018-04-09 | 2018-04-20 |  | 1d | 0d |  | 160h |
| 73 | 1.11.3.1 | Trainers |  | 5d | 2018-04-09 | 2018-04-13 | 64 | 6d |  | Care Staff Rep | 40h |
| 74 | 1.11.3.2 | Materials |  | 5d | 2018-04-09 | 2018-04-13 | 64 | 6d |  | Care Staff Rep | 40h |
| 75 | 1.11.3.3 | Documentation |  | 10d | 2018-04-09 | 2018-04-20 | 64 | 1d |  | Care Staff Rep | 80h |
| 76 | 1.12 | **Make interface coding changes** |  | 16d | 2018-04-16 | 2018-05-07 |  | 0d |  |  | 576h |
| 77 | 1.12.1 | **Code Changes** |  | 10d | 2018-04-16 | 2018-04-27 |  | 0d |  |  | 480h |
| 78 | 1.12.1.1 | Sending system changes |  | 10d | 2018-04-16 | 2018-04-27 | 47 | 0d |  | Vendor A; Vendor B | 160h |
| 79 | 1.12.1.2 | Receiving system changes |  | 10d | 2018-04-16 | 2018-04-27 | 47 | 0d |  | Vendor A; Vendor B | 160h |
| 80 | 1.12.1.3 | Other (IE changes, ) |  | 10d | 2018-04-16 | 2018-04-27 | 47 | 0d |  | Vendor A; Vendor B | 160h |
| 81 | 1.12.1.4 | Complete coding | milestone | 0d | 2018-04-27 | 2018-04-27 | 80 | 0d |  | Vendor A; Vendor B |  |
| 82 | 1.12.2 | Perform all internal testing |  | 5d | 2018-04-30 | 2018-05-04 | 77 | 0d |  | Vendor A; Vendor B | 80h |
| 83 | 1.12.3 | Move code to test sytem |  | 1d | 2018-05-07 | 2018-05-07 | 82 | 0d |  | Vendor A; Vendor B | 16h |

Notes:
- 64: Include alternative, down-time, and/or emergency work-flows
- 68: Include alternative, down-time, and/or emergency work-flows

| ID | WBS | Task | Duration | Start | Finish | Predecessors | Total slack | Free slack | Resources | Work |
| --- | --- | --- | --- | --- | --- | --- | --- | --- | --- | --- |
| 84 | 1.13 | **Testing** | 29d | 2018-04-23 | 2018-05-31 |  | 0d |  |  | 936h |
| 85 | 1.13.1 | **Document Testing Plan** | 5d | 2018-04-23 | 2018-04-27 |  | 1d | 0d |  | 360h |
| 86 | 1.13.1.1 | document actors/scenario | 5d | 2018-04-23 | 2018-04-27 | 72 | 1d |  | Project Manager; IT; Partner IT | 120h |
| 87 | 1.13.1.2 | document data /scenario | 5d | 2018-04-23 | 2018-04-27 | 72 | 1d |  | Project Manager; IT; Partner IT | 120h |
| 88 | 1.13.1.3 | develop tests for all scenarios | 5d | 2018-04-23 | 2018-04-27 | 72 | 1d |  | Project Manager; IT; Partner IT | 120h |
| 89 | 1.13.2 | Confirm access to test system | 5d | 2018-04-30 | 2018-05-04 | 85 | 1d |  | Partner IT | 40h |
| 90 | 1.13.3 | **Unit test** | 18d | 2018-05-08 | 2018-05-31 |  | 0d |  |  | 536h |
| 91 | 1.13.3.1 | send test transaction | 5d | 2018-05-08 | 2018-05-14 | 83, 89 | 0d |  | IT; Partner IT | 80h |
| 92 | 1.13.3.2 | confirm delivery | 1d | 2018-05-15 | 2018-05-15 | 91 | 0d |  | Partner IT | 8h |
| 93 | 1.13.3.3 | Process message | 1d | 2018-05-16 | 2018-05-16 | 92 | 0d |  | Care Staff Rep; IT; Partner Care rep; Partner IT | 32h |
| 94 | 1.13.3.4 | validate data | 1d | 2018-05-17 | 2018-05-17 | 93 | 0d |  | Care Staff Rep; Partner Care rep | 16h |
| 95 | 1.13.3.5 | Unit test complete | 10d | 2018-05-18 | 2018-05-31 | 94 | 0d |  | IT; Partner IT; Team; Vendor A; Vendor B | 400h |
| 96 | 1.14 | **Go Live** | 46d | 2018-04-09 | 2018-06-11 |  | 30d |  |  | 344h |
| 97 | 1.14.1 | Document Go Live Plan | 5d | 2018-04-09 | 2018-04-13 | 63, 45 | 71d |  | Project Manager | 40h |
| 98 | 1.14.2 | Perform work flow training | 5d | 2018-06-01 | 2018-06-07 | 95 | 32d |  | Care Staff Rep; Partner Care rep; Training Resource | 120h |
| 99 | 1.14.3 | Move code to live | 1d | 2018-06-01 | 2018-06-01 | 95 | 0d |  | Vendor A; Vendor B | 16h |
| 100 | 1.14.4 | **Production test** | 5d | 2018-06-04 | 2018-06-08 |  | 0d |  |  | 160h |
| 101 | 1.14.4.1 | Paralell end-to-end testing with Real Patient data | 5d | 2018-06-04 | 2018-06-08 | 99 | 0d |  | Care Staff Rep; IT; Partner Care rep; Partner IT | 160h |
| 102 | 1.14.5 | Go Live | 1d | 2018-06-11 | 2018-06-11 | 101 | 0d |  | Team | 8h |
| 103 | 1.15 | **Measure performance, support and debug** | 30d | 2018-06-12 | 2018-07-23 |  | 0d |  | Team | 720h |
| 104 | 1.15.1 | Objective1 | 30d | 2018-06-12 | 2018-07-23 | 102 | 0d |  | Team | 240h |
| 105 | 1.15.2 | Objective 2 | 30d | 2018-06-12 | 2018-07-23 | 102 | 0d |  | Team | 240h |
